# QUEBRADAS CAÑETE

Schedule from Primavera P6, 2024-03-15 to 2024-12-30, data date 2024-03-15.
Must finish by 2024-12-30

## Calendars

- Huara III: Mon-Sat 07:00-16:00; Sun off.

## Resources

| Resource | Group |
| --- | --- |
| HH | labor |

## Schedule

| ID | WBS | Activity | Type | Duration | Start | Finish | Predecessors | Total float | Free float | Resources |
| --- | --- | --- | --- | --- | --- | --- | --- | --- | --- | --- |
|  | 2 | **HITOS** |  |  | 2024-03-15 | 2024-12-30 |  |  |  |  |
| A2670 |  | Inicio de obra - Acceso al Sitio | milestone | 0d | 2024-03-15 | 2024-03-15 |  | 0d |  |  |
| A2680 |  | Inicio de Obras Peliminares | milestone | 0d | 2024-04-05 | 2024-04-05 | A2670 SS+18d | 0d |  |  |
| A2690 |  | Inicio de Obras_ Quebrada San Jeronimo | milestone | 0d | 2024-05-02 | 2024-05-02 | A2680 SS+23d | 0d |  |  |
| A2700 |  | Inicio de Obras_ Quebrada San Condoray | milestone | 0d | 2024-05-02 | 2024-05-02 | A2680 SS+23d | 208d |  |  |
| A2710 |  | Inicio de Obras_ Quebrada San Jacayita | milestone | 0d | 2024-05-02 | 2024-05-02 | A2680 SS+23d | 208d |  |  |
| A2720 |  | Inicio de Obras_ Quebrada San Picamaran | milestone | 0d | 2024-05-02 | 2024-05-02 | A2680 SS+23d | 208d |  |  |
| A2750 |  | Culminación de Obras | milestone | 0d | 2024-12-30 | 2024-12-30 | A2670 SF+249d, A2780 FF | 0d |  |  |
|  | 5 | **TRABAJOS PRELIMINARES** |  |  | 2024-03-15 | 2024-12-27 |  |  |  |  |
|  | 1 | **OBRAS PROVISIONALES** |  |  | 2024-03-15 | 2024-05-11 |  |  |  |  |
| A1560 |  | Desmovilización de Maquinaria Pesada |  | 15d | 2024-03-15 | 2024-04-01 |  | 234d |  | HH [135 h] |
| A2830 |  | Movilización de Maquinaria Pesada |  | 15d | 2024-03-16 | 2024-04-02 | A2670 SS+1d | 12d | 8d | HH [135 h] |
| A1550 |  | Campamento Provisional de Obra |  | 39d | 2024-03-18 | 2024-05-01 | A2670 SS+2d | 0d |  | HH [351 h] |
| A1600 |  | Instalación de Plantas de Concreto |  | 48d | 2024-03-18 | 2024-05-11 | A2670 SS+2d | 0d |  |  |
| A1580 |  | Habilitación de plataformas |  | 27d | 2024-03-20 | 2024-04-19 | A2670 SS+4d | 24d | 22d | HH [243 h] |
|  | 2 | **MANTENIMIENTO DE VIAS** |  |  | 2024-03-19 | 2024-12-27 |  |  |  |  |
| A1590 |  | Mejoramiento y Habilitación de caminos de acceso |  | 24d | 2024-03-19 | 2024-04-15 | A2670 SS+3d | 2d | 0d | HH [216 h] |
| A1570 |  | Limpieza manual de material vegetal y de residuos |  | 5d | 2024-04-12 | 2024-04-17 | A2670 SS+24d | 4d | 0d | HH [45 h] |
| A1640 |  | Mantenimiento de caminos de acceso |  | 220d | 2024-04-16 | 2024-12-27 | A1580 SS+1d, A1590 | 2d | 0d | HH [1980 h] |
|  | 6 | **DEMOLICIONES** |  |  | 2024-04-12 | 2024-07-17 |  |  |  |  |
| A1690 |  | Demolicion de Canales en Quebradas |  | 83d | 2024-04-12 | 2024-07-17 | A2680 SS+5d, A1570 SS | 4d | 0d | HH [747 h] |
| A1720 |  | Demolicion de Baden |  | 15d | 2024-04-17 | 2024-05-03 | A1690 SS+4d | 178d | 0d | HH [135 h] |
| A1730 |  | Demolicion de Pavimentos |  | 26d | 2024-04-22 | 2024-05-21 | A1720 SS+4d | 178d | 0d | HH [234 h] |
| A1740 |  | Demolicion de Veredas |  | 5d | 2024-04-26 | 2024-05-01 | A1730 SS+4d | 178d | 0d | HH [45 h] |
| A1750 |  | Demolicion de Cerco Perimétrico |  | 8d | 2024-05-01 | 2024-05-09 | A1740 SS+4d | 178d | 0d | HH [72 h] |
| A1760 |  | Eliminacion de material de demolicion |  | 27d | 2024-05-06 | 2024-06-05 | A1750 SS+4d | 178d | 168d | HH [243 h] |

| ID | WBS | Activity | Duration | Start | Finish | Predecessors | Total float | Free float | Resources |
| --- | --- | --- | --- | --- | --- | --- | --- | --- | --- |
|  | 4 | **CONSTRUCCION DE QUEBRADAS** |  | 2024-04-12 | 2024-12-30 |  |  |  |  |
|  | 8 | **MOVIMIENTO DE TIERRAS** |  | 2024-05-02 | 2024-12-30 |  |  |  |  |
| A1780 |  | Desbroce | 13d | 2024-05-02 | 2024-05-16 | A2690 SS, A1550 | 0d |  | HH [117 h] |
| A1790 |  | Excavación de cimentación | 103d | 2024-05-04 | 2024-08-31 | A1780 SS+2d | 0d |  | HH [927 h] |
| A1800 |  | Perfilado y conformación de Plataforma de fundación | 51d | 2024-05-07 | 2024-07-04 | A1790 SS+2d | 0d |  | HH [459 h] |
| A1810 |  | Conformación de material excedente en DME | 64d | 2024-05-09 | 2024-07-22 | A1800 SS+2d | 4d | 0d | HH [576 h] |
| A1820 |  | Conformación de material excedente en DMO | 30d | 2024-05-11 | 2024-06-14 | A1810 SS+2d | 4d | 0d | HH [270 h] |
| A1830 |  | Relleno con material granular (incluye extracción de material, zarandeo y combinación de material) | 8d | 2024-05-14 | 2024-05-22 | A1820 SS+2d | 4d | 0d | HH [72 h] |
| A1840 |  | Relleno Estructural | 120d | 2024-08-13 | 2024-12-30 | A1830 SS+2d, A1930 SS+30d | 0d |  | HH [1080 h] |
| A1850 |  | Suministro de Roca | 34d | 2024-08-15 | 2024-09-23 | A1840 SS+2d | 83d | 0d | HH [306 h] |
| A1860 |  | Colocación de Roca en Uña | 33d | 2024-08-17 | 2024-09-24 | A1850 SS+2d | 83d |  | HH [297 h] |
|  | 7 | **ESTRUCTURAS DE CANALIZACION** |  | 2024-05-13 | 2024-12-30 |  |  |  |  |
|  | 1 | **ROCA RECEBADA** |  | 2024-05-13 | 2024-12-30 |  |  |  |  |
| A1900 |  | Roca Recebada | 199d | 2024-05-13 | 2024-12-30 | A1800 SS+5d, A1600 | 0d |  | HH [1791 h] |
|  | 3 | **MURO DE CONTENCIÓN CICLOPEO** |  | 2024-05-30 | 2024-12-23 |  |  |  |  |
|  | 1 | **Obras de Concreto Simple** |  | 2024-05-30 | 2024-12-23 |  |  |  |  |
| A2470 |  | Concreto Clase F (F'C=100 KG/CM2) - Solados | 61d | 2024-05-30 | 2024-08-08 | A1900 SS+15d | 0d |  | HH [549 h] |
| A2520 |  | Encofrado y Desencofrado Cara Vista | 170d | 2024-06-04 | 2024-12-18 | A2510 FF | 0d |  | HH [1530 h] |
| A2510 |  | Encofrado y Desencofrado Cara Oculta | 169d | 2024-06-05 | 2024-12-18 | A2470 SS+5d | 0d |  | HH [1521 h] |
| A2490 |  | Concreto Clase A (F'C=280 KG/CM2)- Premezclado - Muros | 170d | 2024-06-08 | 2024-12-23 | A2520 FF+4d | 6d | 161d | HH [1530 h] |
| A1930 |  | Concreto Clase A (F'C=280 KG/CM2)-Premezclado - muros +30% PM DMAX=6" | 143d | 2024-07-09 | 2024-12-21 | A2520 FF+3d | 0d |  | HH [1287 h] |
| A1940 |  | Concreto Clase A (F'C=280 KG/CM2)- Premezclado - muros+30% PM DMAX=4" | 8d | 2024-12-14 | 2024-12-23 | A2520 FF+4d, A2490 SS+1d | 6d |  | HH [72 h] |
|  | 4 | **MURO DE CONTENCIÓN CON RAPIDA** |  | 2024-07-04 | 2024-12-18 |  |  |  |  |
|  | 2 | **Obras de Concreto Armado** |  | 2024-07-04 | 2024-12-18 |  |  |  |  |
| A2020 |  | Acero FY=4200 KG/CM2, Grado 60 | 133d | 2024-07-04 | 2024-12-05 | A2510 SS+25d | 10d | 0d | HH [1197 h] |
| A2000 |  | Encofrado y Desencofrado Cara Oculta | 107d | 2024-08-09 | 2024-12-11 | A1930 SS, A2020 FF+5d | 10d | 0d | HH [963 h] |
| A2010 |  | Encofrado y Desencofrado Cara Vista | 107d | 2024-08-09 | 2024-12-11 | A2000 FF | 16d | 6d | HH [963 h] |
| A1950 |  | Concreto Clase A (F'C=280 KG/CM2)- Premezclado - muros | 92d | 2024-08-27 | 2024-12-11 | A2000 FF | 10d | 0d | HH [828 h] |
| A2030 |  | Geocompuesto de Drenaje | 53d | 2024-10-18 | 2024-12-18 | A1950 SS+45d | 10d | 0d | HH [477 h] |
| A2040 |  | Tubo PVC - D=6" | 22d | 2024-11-16 | 2024-12-11 | A2000 FF | 16d | 6d | HH [198 h] |
| A2050 |  | Tubo PVC - D=4" | 16d | 2024-11-23 | 2024-12-11 | A2000 FF, A2040 SS | 16d | 6d | HH [144 h] |

| ID | WBS | Activity | Duration | Start | Finish | Predecessors | Total float | Free float | Resources |
| --- | --- | --- | --- | --- | --- | --- | --- | --- | --- |
|  | 2 | **MUROS DE CONTENCIÓN** |  | 2024-10-18 | 2024-12-07 |  |  |  |  |
|  | 1 | **Obras de Concreto Simple** |  | 2024-10-18 | 2024-10-22 |  |  |  |  |
| A2810 |  | Concreto Clase F (F'C=100 KG/CM2) - Solados | 4d | 2024-10-18 | 2024-10-22 | A2030 SS | 19d | 0d | HH [36 h] |
|  | 2 | **Obras de Concreto Armado** |  | 2024-10-23 | 2024-12-07 |  |  |  |  |
| A1960 |  | Encofrado y Desencofrado Cara Oculta | 17d | 2024-10-23 | 2024-11-11 | A2810 | 19d | 0d | HH [153 h] |
| A1970 |  | Encofrado y Desencofrado Cara Vista | 17d | 2024-10-23 | 2024-11-11 | A1960 FF, A2530 FF | 19d | 0d | HH [153 h] |
| A2530 |  | Acero FY=4200 KG/CM2, Grado 60 | 14d | 2024-10-26 | 2024-11-11 | A2810 FS+3d | 19d | 0d | HH [126 h] |
| A2500 |  | Concreto Clase A (F'C=280 KG/CM2)- Premezclado - Cimentacion | 4d | 2024-11-12 | 2024-11-15 | A1970 | 19d | 0d | HH [36 h] |
| A2820 |  | Concreto Clase A (F'C=280 KG/CM2)- Premezclado - Muros | 4d | 2024-11-16 | 2024-11-20 | A2500 | 19d | 0d | HH [36 h] |
| A2540 |  | Barrera de Seguridad Rigida Tipo New Jersey Prefabricada | 15d | 2024-11-21 | 2024-12-07 | A2820 | 19d | 9d | HH [135 h] |
|  | 4 | **PASO SUPERIOR TIPO MARCO** |  | 2024-05-18 | 2024-10-23 |  |  |  |  |
|  | 1 | **Obras de Concreto Simple** |  | 2024-05-18 | 2024-05-29 |  |  |  |  |
| A2090 |  | Encofrado y Desencofrado en Estructuras | 2d | 2024-05-18 | 2024-05-20 | A1900 SS+5d | 0d |  | HH [18 h] |
| A2760 |  | Concreto Clase F (F'C=100 KG/CM2) - Solados | 8d | 2024-05-21 | 2024-05-29 | A2090 | 0d |  | HH [72 h] |
|  | 2 | **Obras de Concreto Armado** |  | 2024-05-20 | 2024-10-23 |  |  |  |  |
| A2140 |  | Encofrado y Desencofrado Cara Oculta | 96d | 2024-05-20 | 2024-09-07 | A2160 FF+3d | 97d | 0d | HH [864 h] |
| A2150 |  | Encofrado y Desencofrado Cara Vista | 96d | 2024-05-20 | 2024-09-07 | A2140 SS | 97d | 21d | HH [864 h] |
| A2160 |  | Acero FY=4200 KG/CM2, Grado 60 | 70d | 2024-06-15 | 2024-09-04 | A2760 FS+14d | 0d |  | HH [630 h] |
| A2120 |  | Concreto Clase A(F'C=280 KG/CM2)- Premezclado - muros | 60d | 2024-07-25 | 2024-10-02 | A2770 SS | 48d | 0d | HH [540 h] |
| A2130 |  | Concreto Clase A(F'C=280 KG/CM2)- Premezclado - Cimentacion | 60d | 2024-07-25 | 2024-10-02 | A2120 SS, A2150 FF | 76d |  | HH [540 h] |
| A2770 |  | Concreto Clase A(F'C=280 KG/CM2)- Premezclado - losas | 41d | 2024-07-25 | 2024-09-10 | A2160 FF+5d | 0d |  | HH [369 h] |
| A2170 |  | Geocompuesto de Drenaje | 9d | 2024-09-11 | 2024-09-20 | A2770 | 86d |  | HH [81 h] |
| A2180 |  | Tubo PVC - D=6" | 3d | 2024-10-03 | 2024-10-05 | A2120 | 73d |  | HH [27 h] |
| A2190 |  | Tubo PVC - D=4" | 3d | 2024-10-03 | 2024-10-05 | A2120 | 73d |  | HH [27 h] |
| A2200 |  | Baranda Metalica Tipica H=0.50M | 3d | 2024-10-21 | 2024-10-23 | A2120 FS+15d | 48d | 44d | HH [27 h] |

| ID | WBS | Activity | Duration | Start | Finish | Predecessors | Total float | Free float | Resources |
| --- | --- | --- | --- | --- | --- | --- | --- | --- | --- |
|  | 5 | **PAVIMENTO RIGIDO** |  | 2024-09-11 | 2024-12-30 |  |  |  |  |
| A1870 |  | Subbase granular | 5d | 2024-09-11 | 2024-09-16 | A2770 | 0d |  | HH [45 h] |
| A2590 |  | Acero FY=4200 KG/CM2, Grado 60 | 23d | 2024-09-17 | 2024-10-12 | A1870 | 67d | 44d | HH [207 h] |
| A2610 |  | Acero Longitudinal (Barra de amarre Ø1/2" Corrugado) | 66d | 2024-09-18 | 2024-12-03 | A1870 FS+1d | 23d | 0d | HH [594 h] |
| A2620 |  | Acero Transversal (Pasa Juntas Dowells Ø 1 1/4" Liso) | 54d | 2024-09-19 | 2024-11-20 | A1870 FS+2d | 0d |  | HH [486 h] |
| A2660 |  | Junta de Aislamiento | 7d | 2024-09-21 | 2024-09-28 | A1870 SS+2d, A2620 SS+2d | 61d |  | HH [63 h] |
| A2630 |  | Canastilla para Ø5/16" para Dowells | 37d | 2024-09-24 | 2024-11-05 | A1870 SS, A2620 SS+4d | 0d |  | HH [333 h] |
| A2650 |  | Junta Transversal de Contraccion | 47d | 2024-09-24 | 2024-11-16 | A1870 SS, A2620 SS, A2630 SS | 0d |  | HH [423 h] |
| A2600 |  | Encofrado y Desencofrado de Pavimientos | 60d | 2024-09-25 | 2024-12-03 | A2620 FF, A2590 FF, A2610 FF | 23d |  | HH [540 h] |
| A2640 |  | Concreto Clase A (F'C=280 KG/CM2)- Premezclado - Losas | 20d | 2024-11-18 | 2024-12-10 | A2660 FF+1d, A2650 | 0d |  | HH [180 h] |
| A2580 |  | Pavimiento Hidraulico (F'C 300KG/CM2) | 17d | 2024-12-11 | 2024-12-30 | A2640 | 0d |  | HH [153 h] |
|  | 3 | **SEÑALIZACION VIAL** |  | 2024-12-11 | 2024-12-25 |  |  |  |  |
| A2730 |  | Instalacion de Señalizacion Vial | 13d | 2024-12-11 | 2024-12-25 | A2580 SS, A2200 SS | 4d |  | HH [117 h] |
|  | 1 | **SOLUCION DE INTERFERENCIAS** |  | 2024-05-13 | 2024-11-20 |  |  |  |  |
| A2270 |  | Solucion de Interferencia Tipo Canales | 165d | 2024-05-13 | 2024-11-20 | A1900 SS | 34d | 0d | HH [1485 h] |
| A2290 |  | Solucion de Interferencia Tipo Badenes | 160d | 2024-05-18 | 2024-11-20 | A2270 SS+5d | 34d | 0d | HH [1440 h] |
| A2280 |  | Solucion de Interferencia Tipo Alcantarillas y Buzones | 155d | 2024-05-24 | 2024-11-20 | A2290 SS+5d | 34d | 0d | HH [1395 h] |
| A2260 |  | Solucion de Interferencia Tipo Sifones | 151d | 2024-05-29 | 2024-11-20 | A2280 SS+4d | 34d | 0d | HH [1359 h] |
| A2250 |  | Solucion de Interferencia Tipo Ducto | 147d | 2024-06-03 | 2024-11-20 | A2260 SS+4d | 34d | 0d | HH [1323 h] |
| A2240 |  | Solucion de Interferencia Tipo Tuberia | 141d | 2024-06-10 | 2024-11-20 | A2250 SS+6d | 34d |  | HH [1269 h] |
|  | 2 | **INFRAESTRUCTURA VERDE Y PAISAJISMO** |  | 2024-07-22 | 2024-12-19 |  |  |  |  |
| A2740 |  | Instalaciones de Paisajismo e Infraestructura Verde | 130d | 2024-07-22 | 2024-12-19 | A1900 SS+60d | 9d |  | HH [1170 h] |
|  | 9 | **TRANSPORTE** |  | 2024-04-12 | 2024-12-25 |  |  |  |  |
| A2370 |  | Transporte de material excedente D<= 1km | 221d | 2024-04-12 | 2024-12-25 | A2830, A1690 SS | 4d | 0d | HH [1989 h] |
| A2380 |  | Transporte de material excedente D> 1km | 221d | 2024-04-12 | 2024-12-25 | A2370 SS | 4d |  | HH [1989 h] |
| A2350 |  | Transporte de material orgánico (a DMO) D<= 1km | 218d | 2024-04-16 | 2024-12-25 | A2830, A1640 SS | 4d | 0d | HH [1962 h] |
| A2360 |  | Transporte de material orgánico (a DMO) D> 1km | 218d | 2024-04-16 | 2024-12-25 | A2350 SS | 4d |  | HH [1962 h] |
| A2410 |  | Transporte de roca D<= 1km | 195d | 2024-05-13 | 2024-12-25 | A2830, A1900 SS | 4d | 0d | HH [1755 h] |
| A2420 |  | Transporte de roca D> 1km | 195d | 2024-05-13 | 2024-12-25 | A2410 SS | 4d |  | HH [1755 h] |
| A2390 |  | Transporte de material de prestamo (afirmado) D<= 1km | 194d | 2024-05-14 | 2024-12-25 | A2830, A1830 SS | 4d | 0d | HH [1746 h] |
| A2400 |  | Transporte de material de prestamo (afirmado) D> 1km | 194d | 2024-05-14 | 2024-12-25 | A2390 SS | 4d |  | HH [1746 h] |
| A2430 |  | Transporte de material de préstamo cantera de rio (cuerpo de terraplén) D<= 1km | 194d | 2024-05-14 | 2024-12-25 | A2830, A1830 SS | 4d | 0d | HH [1746 h] |
| A2440 |  | Transporte de material de préstamo cantera de rio (cuerpo de terraplén) D> 1km | 194d | 2024-05-14 | 2024-12-25 | A2430 SS | 4d |  | HH [1746 h] |

| ID | WBS | Activity | Duration | Start | Finish | Predecessors | Total float |
| --- | --- | --- | --- | --- | --- | --- | --- |
|  | 1 | **FIN DE OBRAS** |  | 2024-12-19 | 2024-12-19 |  |  |
| A2780 |  | Fin de Obras | 0d | 2024-12-19 | 2024-12-19 | A1760, A2010, A2030, A2050, A2540 | 10d |
